# GARAGEM & DRIVE-IN

Schedule from MS Project, 2021-11-01 to 2021-12-22, status date 2021-12-21, A marks actual dates.
Método AP vs AB
BarbecanaSI:V6/FTF/0/0/60/0/15424756/0/(None)/LOE/(None)/X/(None)/PP/(None)/1/11133507/T0ATF/F0/0/=0%/F0/0/=0%/F0/10/=0%/F0/10/=0%/F0/0/=0%/F0/0/=0%/F0/0/=0%/F0/0/=0%/F4/0/=0%/T4/0/=1/T4/0/=1/T0/0/=0%/T0/0/<5%/T0/0/>90%/T0/0/<5%/T0/44d/<5%/T0/0/=0%/F22/44d/<5%/F0/0/=0%/F4/0/=0%/F12/0/=0%/T1/0/<5%/T37/120w/=0%/F5/0/>0,95/F12/0/>0,95/F0/0/=0%/F0/0/=0%/F0/0/=0%/F0/0/=0%/T0/0/=0%/F23/44d/=0%

## Calendars

- Corridos: Mon-Sun 09:00-12:00, 13:00-18:00.

## Schedule

| ID | WBS | Task | Type | Duration | Start | Finish | Predecessors | Complete | Baseline start | Baseline finish | Baseline duration | Baseline cost |
| --- | --- | --- | --- | --- | --- | --- | --- | --- | --- | --- | --- | --- |
| 1 | 1 | **Marcos** |  | 51d | 2021-11-01 A | 2021-12-22 A |  | 100% | 2021-11-01 | 2021-12-11 | 40d | -0 |
| 2 | 1.1 | Início do Projeto | milestone | 0ed | 2021-11-01 A | 2021-11-01 A |  | 100% | 2021-11-01 | 2021-11-01 | 0ed |  |
| 3 | 1.2 | Término do Projeto | milestone | 0d | 2021-12-22 A | 2021-12-22 A | 13 | 100% | 2021-12-11 | 2021-12-11 | 0d |  |
| 4 | 2 | **GARAGEM** |  | 51d | 2021-11-01 A | 2021-12-22 A |  | 100% | 2021-11-01 | 2021-12-11 | 40d |  |
| 5 | 2.1 | Escavar Fundação |  | 5ed | 2021-11-01 A | 2021-11-06 A | 2 | 100% | 2021-11-01 | 2021-11-06 | 5ed |  |
| 6 | 2.2 | Concreto da Fundação |  | 5ed | 2021-11-04 A | 2021-11-09 A | 5 | 100% | 2021-11-06 | 2021-11-09 | 3ed |  |
| 7 | 2.3 | Alvenaria h= 1,0m |  | 6ed | 2021-11-09 A | 2021-11-15 A | 6 | 100% | 2021-11-09 | 2021-11-15 | 6ed |  |
| 8 | 2.4 | Alvenaria h= 3,0m |  | 17ed | 2021-11-15 A | 2021-12-02 A | 7 | 100% | 2021-11-15 | 2021-11-29 | 14ed |  |
| 9 | 2.5 | Laje de Piso |  | 5ed | 2021-11-15 A | 2021-11-20 A | 7 | 100% | 2021-11-15 | 2021-11-19 | 4ed |  |
| 10 | 2.6 | Estrutura do Teto |  | 6ed | 2021-12-05 A | 2021-12-11 A | 8, 9 | 100% | 2021-11-29 | 2021-12-05 | 6ed |  |
| 11 | 2.7 | Cobertura |  | 5ed | 2021-12-09 A | 2021-12-14 A | 10 | 100% | 2021-12-05 | 2021-12-07 | 2ed |  |
| 12 | 2.8 | Fornecimento e colocação de Esquadrias |  | 5ed | 2021-12-09 A | 2021-12-14 A | 10 | 100% | 2021-12-05 | 2021-12-07 | 2ed |  |
| 13 | 2.9 | Pintura e Limpeza |  | 4ed | 2021-12-18 A | 2021-12-22 A | 12, 11, 17 | 100% | 2021-12-07 | 2021-12-11 | 4ed |  |
| 14 | 3 | **DRIVE-IN** |  | 47d | 2021-11-01 A | 2021-12-18 A |  | 100% | 2021-11-01 | 2021-12-01 | 30d |  |
| 15 | 3.1 | Limpeza e Escavação |  | 22ed | 2021-11-01 A | 2021-11-23 A | 2 | 100% | 2021-11-01 | 2021-11-16 | 15ed |  |
| 16 | 3.2 | Base de Brita |  | 19ed | 2021-11-18 A | 2021-12-07 A | 15 | 100% | 2021-11-16 | 2021-11-26 | 10ed |  |
| 17 | 3.3 | Concreto Betuminoso |  | 9ed | 2021-12-09 A | 2021-12-18 A | 16 | 100% | 2021-11-26 | 2021-12-01 | 5ed |  |

Notes:
- 6: Referência: O empreiteiro teve um problema de MO, então demorou 3 dias extras para concluir a atividade G2.
- 8: Referência: A atividade G4 não começou imediatamente após a conclusão de sua predecessora, conforme planejado, devido ao atraso de 1 dia do fornecedor de tijolos da contratada.
- 9: Referência: A empreiteira avisou o proprietário sobre a necessidade de aumentar a espessura da laje. Essa mudança exigiu 1 dia extra para ser realizada.
- 11: Referência: O empreiteiro demorou mais 3 dias para concluir a atividade G6.
- 12: Referência: O proprietário mudou de idéia sobre o tipo de porta usada para a garagem, então ordenou que o empreiteiro fizesse alterações. Isso causou 3 dias extras de trabalho.
- 15: Referência: A contratada encontrou condições de solo adversas imprevistas durante a escavação do drive-in.
- 16: Referência: Após 5 dias de trabalho na atividade D2, o proprietário suspendeu os trabalhos por 3 dias, pois estava sendo tomada uma decisão sobre a adequação do material da base.
- 17: Referência: Houve um atraso de 4 dias por parte do proprietário em disponibilizar para o contratante um equipamento fornecido pelo proprietário para a atividade D3
